# Project Schedule

Schedule from MS Project, 2014-01-13 to 2014-04-18.
Cupertino Electric, inc.

## Calendars

- Standard: Mon-Fri 08:00-12:00, 13:00-17:00; Sat-Sun off.

## Schedule

| ID | WBS | Task | Type | Duration | Start | Finish | Predecessors | Total slack | Free slack | Constraint |
| --- | --- | --- | --- | --- | --- | --- | --- | --- | --- | --- |
| 1 | 1 | **Construction** |  | 70d | 2014-01-13 | 2014-04-18 |  | 0d |  |  |
| 2 | 1.1 | Mobilization |  | 2d | 2014-01-13 | 2014-01-14 |  | 0d |  | start no earlier than 2014-01-13 |
| 3 | 1.2 | Layout |  | 3d | 2014-01-14 | 2014-01-16 | 2SS+1d | 0d |  |  |
| 4 | 1.3 | Grind/Seal Concrete Floors |  | 7d | 2014-01-16 | 2014-01-24 | 3SS+2d | 0d |  |  |
| 5 | 1.4 | Overhead MEP |  | 2w | 2014-01-20 | 2014-01-31 | 4SS+2d | 0d |  |  |
| 6 | 1.5 | Overhead Cabling Hangers |  | 2w | 2014-01-20 | 2014-01-31 | 4SS+2d | 55d |  |  |
| 7 | 1.6 | Frame Walls |  | 2.5w | 2014-01-27 | 2014-02-12 | 5SS+1w | 0d |  |  |
| 8 | 1.7 | Rough-in MEP in Walls |  | 2w | 2014-01-29 | 2014-02-11 | 7SS+2d | 0d |  |  |
| 9 | 1.8 | Rough-in AV in Walls |  | 2w | 2014-01-29 | 2014-02-11 | 7SS+2d | 0d |  |  |
| 10 | 1.9 | Rough-in Furniture in Walls |  | 2w | 2014-01-29 | 2014-02-11 | 7SS+2d | 0d |  |  |
| 11 | 1.10 | Rough-in Security in Walls |  | 2w | 2014-01-29 | 2014-02-11 | 7SS+2d | 0d |  |  |
| 12 | 1.11 | Rough-in IT in Walls |  | 2w | 2014-01-29 | 2014-02-11 | 7SS+2d | 0d |  |  |
| 13 | 1.12 | Wall Inspection |  | 2d | 2014-02-12 | 2014-02-13 | 8, 9, 10, 11, 12 | 0d |  |  |
| 14 | 1.13 | Gyp Cover |  | 5d | 2014-02-14 | 2014-02-20 | 13 | 0d |  |  |
| 15 | 1.14 | Taping |  | 9d | 2014-02-19 | 2014-03-03 | 14SS+3d | 0d |  |  |
| 16 | 1.15 | Frame Gyp Soffits/Ceilings |  | 8d | 2014-02-03 | 2014-02-12 | 7SS+1w | 29d | 0d |  |
| 17 | 1.16 | MEP Drops in Gyp Soffits/Ceilings |  | 8d | 2014-02-10 | 2014-02-19 | 16SS+5d | 29d | 0d |  |
| 18 | 1.17 | Gyp Soffit/Ceiling Inspection |  | 2d | 2014-02-20 | 2014-02-21 | 17 | 29d | 0d |  |
| 19 | 1.18 | Gyp Soffit/Ceiling Cover up |  | 4d | 2014-02-24 | 2014-02-27 | 18 | 29d | 0d |  |
| 20 | 1.19 | Gyp Soffit/Ceiling Taping |  | 7d | 2014-02-28 | 2014-03-10 | 19 | 29d |  |  |
| 21 | 1.20 | Painting |  | 3w | 2014-02-21 | 2014-03-13 | 15SS+2d | 0d |  |  |
| 22 | 1.21 | Acoustic Ceilings |  | 2w | 2014-02-25 | 2014-03-10 | 21SS+2d | 0d |  |  |
| 23 | 1.22 | MEP Drops in Ceilings |  | 2w | 2014-02-27 | 2014-03-12 | 22SS+2d | 27d |  |  |
| 24 | 1.23 | Cabling Above Ceiling |  | 2w | 2014-02-27 | 2014-03-12 | 22SS+2d | 0d |  |  |
| 25 | 1.24 | Ceiling Inspection |  | 2d | 2014-03-13 | 2014-03-14 | 24 | 0d |  |  |
| 26 | 1.25 | Drop Ceiling Tile |  | 1w | 2014-03-17 | 2014-03-21 | 25 | 0d |  |  |
| 27 | 1.26 | Door Frames |  | 1w | 2014-02-27 | 2014-03-05 | 21SS+4d | 18d | 0d |  |
| 28 | 1.27 | Measure Glass |  | 3d | 2014-03-06 | 2014-03-10 | 27 | 18d | 0d |  |
| 29 | 1.28 | Fab Glass |  | 1d | 2014-03-11 | 2014-03-11 | 28 | 18d | 0d |  |
| 30 | 1.29 | Set Glass |  | 2w | 2014-03-12 | 2014-03-25 | 29 | 18d |  |  |
| 31 | 1.30 | Millwork |  | 3w | 2014-03-14 | 2014-04-03 | 21 | 6d | 0d |  |
| 32 | 1.31 | Finish Plumbing and Electrical |  | 2w | 2014-03-28 | 2014-04-10 | 31SS+2w | 6d |  |  |
| 33 | 1.32 | Ready for Floor Coverings | milestone | 0d | 2014-03-20 | 2014-03-20 | 26SS+4d | 0d |  |  |
| 34 | 1.33 | Floor Coverings |  | 2w | 2014-03-21 | 2014-04-03 | 33 | 0d |  |  |
| 35 | 1.34 | Ready for Furniture | milestone | 0d | 2014-03-27 | 2014-03-27 | 34SS+1w | 3.5d | 0d |  |
| 36 | 1.35 | Furniture |  | 2.5w | 2014-03-28 | 2014-04-15 | 35 | 3.5d | 0d |  |
| 37 | 1.36 | Electrical and Cabling at Furniture |  | 2w | 2014-04-01 | 2014-04-14 | 36SS+2d | 4d |  |  |
| 38 | 1.37 | Punch List |  | 2w | 2014-04-04 | 2014-04-17 | 34 | 0d |  |  |
| 39 | 1.38 | Final FF&E |  | 2w | 2014-04-07 | 2014-04-18 | 34FS+1d | 0d |  |  |
| 40 | 1.39 | Final Inspections |  | 3d | 2014-04-16 | 2014-04-18 | 38SS+8d | 0d |  |  |
| 41 | 1.40 | Project Complete | milestone | 0d | 2014-04-18 | 2014-04-18 | 40 | 0d |  |  |
